# GLSR VV

Schedule from MS Project, 2019-02-16 to 2019-08-30, 24 hours a day.

## Calendars

- 24 Hours: Mon-Sat 00:00-24:00; Sun off. Exceptions (off unless hours are given): 2019-05-01, 2019-08-15, 2019-08-25 08:00-12:00, 13:00-17:00.

## Schedule

| ID | WBS | Task | Duration | Start | Finish | Predecessors | Total slack | Free slack | Constraint |
| --- | --- | --- | --- | --- | --- | --- | --- | --- | --- |
| 1 | 1 | **MAHINDRA WORLD CITY, PUDUVOYAL- Program Schedule for GLSR** | 165.67d | 2019-02-16 | 2019-08-30 |  | 0d |  |  |
| 2 | 1.1 | Earth work excavation | 10d | 2019-02-16 | 2019-02-28 |  | 4d |  |  |
| 3 | 1.2 | Compaction and testing | 4d | 2019-03-05 | 2019-03-09 | 2 | 18.67d | 0d | start no earlier than 2019-03-05 |
| 4 | 1.3 | PCC - Collection pit | 1d | 2019-03-09 | 2019-03-11 | 3 | 19d | 7.38d |  |
| 5 | 1.4 | Raft - collection pit-rebar | 1d | 2019-03-19 | 2019-03-20 | 4 | 11.29d | 0d | finish no earlier than 2019-03-20 |
| 6 | 1.5 | Raft - collection pit-shuttering | 1d | 2019-03-20 | 2019-03-21 | 5 | 11.62d | 0d |  |
| 7 | 1.6 | Raft - collection pit-concrete | 1d | 2019-03-21 | 2019-03-22 | 6 | 11.62d | 0d |  |
| 8 | 1.7 | wall up to base | 2d | 2019-03-22 | 2019-03-25 | 7 | 11.62d | 0d |  |
| 9 | 1.8 | hard core layer | 2d | 2019-03-25 | 2019-03-27 | 8 | 11.62d | 0d |  |
| 10 | 1.9 | PCC 1:4:8 | 2d | 2019-04-09 | 2019-04-11 | 9 | 0.67d | 0d | start no earlier than 2019-04-09 |
| 11 | 1.10 | reinforcement for raft | 10d | 2019-04-11 | 2019-04-23 | 10 | 0.67d | 0d |  |
| 12 | 1.11 | shuttering for raft | 4d | 2019-04-23 | 2019-04-27 | 11 | 0.67d | 0d |  |
| 13 | 1.12 | RCC Raft concrete | 2d | 2019-04-27 | 2019-04-30 | 12 | 0.67d | 0d |  |
| 14 | 1.13 | RCC wall starter marking | 1d | 2019-04-30 | 2019-05-02 | 13 | 0.67d | 0d |  |
| 15 | 1.14 | RCC wall startrer shuttering and concreting (outer wall) | 2d | 2019-05-02 | 2019-05-04 | 14 | 0.67d | 0d |  |
| 16 | 1.15 | RCC wall startrer shuttering and concreting (inner wall) | 2d | 2019-05-04 | 2019-05-07 | 15 | 0.67d | 0d |  |
| 17 | 1.16 | RCC wall upto 1.2 Rm- rebar | 2d | 2019-05-07 | 2019-05-09 | 16 | 0.67d | 0d |  |
| 18 | 1.17 | RCC wall upto 1.2 Rm- shuttering | 3d | 2019-05-09 | 2019-05-13 | 17 | 0.67d | 0d |  |
| 19 | 1.18 | RCC wall upto 1.2 Rm- concreting | 1d | 2019-05-13 | 2019-05-14 | 18 | 0.67d | 0d |  |
| 20 | 1.19 | RCC wall upto 2.4 Rm-rebar | 2d | 2019-05-14 | 2019-05-16 | 19 | 0.67d | 0d |  |
| 21 | 1.20 | RCC wall upto 2.4 Rm-shuttering | 4d | 2019-05-16 | 2019-05-21 | 20 | 0.67d | 0d |  |
| 22 | 1.21 | RCC wall upto 2.4 Rm-concreting | 1d | 2019-05-21 | 2019-05-22 | 21 | 0.67d | 0d |  |
| 23 | 1.22 | RCC wall upto 3.55 Rm-rebar | 2d | 2019-05-22 | 2019-05-24 | 22 | 0.67d | 0d |  |
| 24 | 1.23 | RCC wall upto 3.55 Rm-shuttering | 4d | 2019-05-24 | 2019-05-29 | 23 | 0.67d | 0d |  |
| 25 | 1.24 | RCC wall upto 3.55 Rm-concreting | 1d | 2019-05-29 | 2019-05-30 | 24 | 0.67d | 0d |  |
| 26 | 1.25 | RCC wall upto 4.5Rm- rebar | 2d | 2019-05-30 | 2019-06-01 | 25 | 0.67d | 0d |  |
| 27 | 1.26 | RCC wall upto 4.5 Rm- shuttering | 5d | 2019-06-01 | 2019-06-07 | 26 | 0.67d | 0d |  |
| 28 | 1.27 | RCC wall upto 4.5 Rm- concreting | 1d | 2019-06-07 | 2019-06-08 | 27 | 0.67d | 0d |  |
| 29 | 1.28 | RCC wall upto 1.2 Rm- rebar (Outer wall) | 2d | 2019-06-08 | 2019-06-11 | 28 | 0.67d | 0d |  |
| 30 | 1.29 | RCC wall upto 1.2 Rm- shuttering | 3d | 2019-06-11 | 2019-06-14 | 29 | 0.67d | 0d |  |
| 31 | 1.30 | RCC wall upto 1.2 Rm- concreting | 1d | 2019-06-14 | 2019-06-15 | 30 | 0.67d | 0d |  |
| 32 | 1.31 | RCC wall upto 2.4 Rm-rebar | 2d | 2019-06-15 | 2019-06-18 | 31 | 0.67d | 0d |  |
| 33 | 1.32 | RCC wall upto 2.4 Rm-shuttering | 3d | 2019-06-18 | 2019-06-21 | 32 | 0.67d | 0d |  |
| 34 | 1.33 | RCC wall upto 2.4 Rm-concreting | 1d | 2019-06-21 | 2019-06-22 | 33 | 0.67d | 0d |  |
| 35 | 1.34 | RCC wall upto 3.55 Rm-rebar | 2d | 2019-06-22 | 2019-06-25 | 34 | 0.67d | 0d |  |
| 36 | 1.35 | RCC wall upto 3.55 Rm-shuttering | 3d | 2019-06-25 | 2019-06-28 | 35 | 0.67d | 0d |  |
| 37 | 1.36 | RCC wall upto 3.55 Rm-concreting | 1d | 2019-06-28 | 2019-06-29 | 36 | 0.67d | 0d |  |
| 38 | 1.37 | RCC wall upto 4.5Rm- rebar | 2d | 2019-06-29 | 2019-07-02 | 37 | 0.67d | 0d |  |
| 39 | 1.38 | RCC wall upto 4.5 Rm- shuttering | 3d | 2019-07-02 | 2019-07-05 | 38 | 0.67d | 0d |  |
| 40 | 1.39 | RCC wall upto 4.5 Rm- concreting | 1d | 2019-07-05 | 2019-07-06 | 39 | 0.67d | 0d |  |
| 41 | 1.40 | doom slab shuttering | 15d | 2019-07-06 | 2019-07-24 | 40 | 0.67d | 0d |  |
| 42 | 1.41 | doom slab reinforcement | 10d | 2019-07-24 | 2019-08-05 | 41 | 0.67d | 0d |  |
| 43 | 1.42 | doom slab concrete | 1d | 2019-08-05 | 2019-08-06 | 42 | 0.67d | 0d |  |
| 44 | 1.43 | deshuttering | 2d | 2019-08-06 | 2019-08-08 | 43 | 0.67d | 0d | start no earlier than 2019-05-24 |
| 45 | 1.44 | waterproofing inner | 3d | 2019-08-12 | 2019-08-16 | 44FS+3d | 0.67d | 0d |  |
| 46 | 1.45 | wall plastering inner | 5d | 2019-08-16 | 2019-08-22 | 45 | 0.67d | 0d |  |
| 47 | 1.46 | wall plastering outer | 7d | 2019-08-22 | 2019-08-30 | 46 | 0.67d |  |  |
| 48 | 1.47 | grano flooring | 3d | 2019-08-22 | 2019-08-25 | 46 | 4.67d |  | start no earlier than 2019-08-22 |
| 49 | 1.48 | plinth protection | 1d | 2019-08-25 | 2019-08-26 |  | 4d |  | start no earlier than 2019-08-25 |
| 50 | 1.49 | cement painting out side | 1d | 2019-08-25 | 2019-08-26 |  | 3.96d |  | finish no earlier than 2019-08-26 |
| 51 | 1.50 | MS hand railing | 5d | 2019-08-20 | 2019-08-25 |  | 4.67d |  | finish no earlier than 2019-08-25 |
| 52 | 1.51 | MS grill and ladder | 5d | 2019-08-20 | 2019-08-25 |  | 0.67d |  | finish no earlier than 2019-08-25 |
| 53 | 1.52 | CLEANING & HANDING OVER | 5d | 2019-08-25 | 2019-08-30 | 52FS-1d | 0d |  | start no earlier than 2019-08-25 |
